# Office Remodel

Schedule from MS Project, 2013-10-07 to 2013-11-25.
Workspace
Paper Division

## Calendars

- Standard: Mon-Fri 08:00-12:00, 13:00-17:00; Sat-Sun off.

## Schedule

| ID | WBS | Task | Type | Duration | Start | Finish | Predecessors | Total slack | Free slack |
| --- | --- | --- | --- | --- | --- | --- | --- | --- | --- |
| 1 | 1 | **Office Workspace Remodel** |  | 35.5d | 2013-10-07 | 2013-11-25 |  | 0d |  |
| 2 | 1.1 | **Space planning** |  | 12d | 2013-10-07 | 2013-10-22 |  | 0d |  |
| 3 | 1.1.1 | Interview space planners |  | 1w | 2013-10-07 | 2013-10-11 |  | 0d |  |
| 4 | 1.1.2 | Hire space planner |  | 2d | 2013-10-14 | 2013-10-15 | 3 | 0d |  |
| 5 | 1.1.3 | Meeting with space planner |  | 2d | 2013-10-16 | 2013-10-17 | 4 | 0d |  |
| 6 | 1.1.4 | Finalize space plan |  | 3d | 2013-10-18 | 2013-10-22 | 5 | 0d |  |
| 7 | 1.1.5 | Space plan complete | milestone | 0d | 2013-10-22 | 2013-10-22 | 6 | 0d |  |
| 8 | 1.2 | **Furniture selection** |  | 12d | 2013-10-18 | 2013-11-04 |  | 14.5d |  |
| 9 | 1.2.1 | Preview furniture selections |  | 2d | 2013-10-18 | 2013-10-21 | 5 | 14.5d | 0d |
| 10 | 1.2.2 | Select new furniture |  | 2d | 2013-10-22 | 2013-10-23 | 9 | 14.5d | 0d |
| 11 | 1.2.3 | Order new furniture |  | 0.5d | 2013-10-24 | 2013-10-24 | 10 | 14.5d | 0d |
| 12 | 1.2.4 | Delivery time |  | 1.5w | 2013-10-24 | 2013-11-04 | 11 | 14.5d | 0d |
| 13 | 1.2.5 | Furniture delivered | milestone | 0d | 2013-11-04 | 2013-11-04 | 12 | 14.5d |  |
| 14 | 1.3 | **Remodel workspace** |  | 14d | 2013-10-23 | 2013-11-11 |  | 0d |  |
| 15 | 1.3.1 | Hire contractor |  | 4d | 2013-10-23 | 2013-10-28 | 7 | 0d |  |
| 16 | 1.3.2 | Remodel workspace |  | 2w | 2013-10-29 | 2013-11-11 | 15 | 0d |  |
| 17 | 1.3.3 | Remodel complete | milestone | 0d | 2013-11-11 | 2013-11-11 | 16 | 0d |  |
| 18 | 1.4 | **New workspace** |  | 9.5d | 2013-11-12 | 2013-11-25 | 14 | 0d |  |
| 19 | 1.4.1 | Hire mover |  | 2d | 2013-11-12 | 2013-11-13 |  | 0d |  |
| 20 | 1.4.2 | Pack workspace |  | 1d | 2013-11-14 | 2013-11-14 | 19 | 0d |  |
| 21 | 1.4.3 | Move equipment |  | 0.5d | 2013-11-15 | 2013-11-15 | 20 | 0d |  |
| 22 | 1.4.4 | Remove existing furniture |  | 1d | 2013-11-15 | 2013-11-18 | 21 | 0d |  |
| 23 | 1.4.5 | Assemble new furniture |  | 2d | 2013-11-18 | 2013-11-20 | 22 | 0d |  |
| 24 | 1.4.6 | Return equipment |  | 1d | 2013-11-20 | 2013-11-21 | 23 | 0d |  |
| 25 | 1.4.7 | Unpack workspace |  | 1d | 2013-11-21 | 2013-11-22 | 24 | 0d |  |
| 26 | 1.4.8 | Workspace final clean |  | 1d | 2013-11-22 | 2013-11-25 | 25 | 0d |  |
| 27 | 1.5 | Workspace remodel complete | milestone | 0d | 2013-11-25 | 2013-11-25 | 18 | 0d |  |
