# Office Remodel

Schedule from MS Project, 2013-10-07 to 2013-11-22.
Workspace
Paper Division

## Calendars

- Standard: Mon-Fri 08:00-12:00, 13:00-17:00; Sat-Sun off.

## Resources

| Resource | Group |
| --- | --- |
| President | Management |
| Office Manager | Management |
| Administrative Assistant | Office Staff |
| Operations Manager | Management |
| Space Planner | Outside Service |
| Janitor | Maintenance |
| Contractor | Contract |
| Mover | Contract |

## Schedule

| ID | WBS | Task | Type | Duration | Start | Finish | Predecessors | Total slack | Free slack | Resources | Work |
| --- | --- | --- | --- | --- | --- | --- | --- | --- | --- | --- | --- |
| 1 | 1 | **Office Workspace Remodel** |  | 34.5d | 2013-10-07 | 2013-11-22 |  | 0d |  |  | 626h |
| 2 | 1.1 | **Space planning** |  | 12d | 2013-10-07 | 2013-10-22 |  | 0d |  |  | 256h |
| 3 | 1.1.1 | Interview space planners |  | 1w | 2013-10-07 | 2013-10-11 |  | 0d |  | President; Operations Manager; Office Manager | 120h |
| 4 | 1.1.2 | Hire space planner |  | 2d | 2013-10-14 | 2013-10-15 | 3 | 0d |  | President; Administrative Assistant | 32h |
| 5 | 1.1.3 | Meeting with space planner |  | 2d | 2013-10-16 | 2013-10-17 | 4 | 0d |  | President; Office Manager; Administrative Assistant; Operations Manager; Space Planner | 80h |
| 6 | 1.1.4 | Finalize space plan |  | 3d | 2013-10-18 | 2013-10-22 | 5 | 0d |  | Space Planner | 24h |
| 7 | 1.1.5 | Space plan complete | milestone | 0d | 2013-10-22 | 2013-10-22 | 6 | 0d |  |  |  |
| 8 | 1.2 | **Furniture selection** |  | 12d | 2013-10-17 | 2013-11-01 |  | 14.5d |  |  | 90h |
| 9 | 1.2.1 | Preview furniture selections |  | 2d | 2013-10-17 | 2013-10-18 | 5SS+1d | 14.5d | 0d | Office Manager; Operations Manager; Administrative Assistant | 48h |
| 10 | 1.2.2 | Select new furniture |  | 2d | 2013-10-21 | 2013-10-22 | 9 | 14.5d | 0d | Office Manager; Operations Manager | 32h |
| 11 | 1.2.3 | Order new furniture |  | 0.5d | 2013-10-23 | 2013-10-23 | 10 | 14.5d | 0d | Administrative Assistant | 4h |
| 12 | 1.2.4 | Delivery time |  | 1.5w | 2013-10-23 | 2013-11-01 | 11 | 14.5d | 0d | Administrative Assistant [10%] | 6h |
| 13 | 1.2.5 | Furniture delivered | milestone | 0d | 2013-11-01 | 2013-11-01 | 12 | 14.5d |  |  |  |
| 14 | 1.3 | **Remodel workspace** |  | 14d | 2013-10-23 | 2013-11-11 |  | 0d |  |  | 144h |
| 15 | 1.3.1 | Hire contractor |  | 4d | 2013-10-23 | 2013-10-28 | 7 | 0d |  | President; Operations Manager | 64h |
| 16 | 1.3.2 | Remodel workspace |  | 2w | 2013-10-29 | 2013-11-11 | 15 | 0d |  | Contractor | 80h |
| 17 | 1.3.3 | Remodel complete | milestone | 0d | 2013-11-11 | 2013-11-11 | 16 | 0d |  |  |  |
| 18 | 1.4 | **New workspace** |  | 8.5d | 2013-11-12 | 2013-11-22 | 14 | 0d |  |  | 136h |
| 19 | 1.4.1 | Hire mover |  | 2d | 2013-11-12 | 2013-11-13 |  | 0d |  | Office Manager; Operations Manager | 32h |
| 20 | 1.4.2 | Pack workspace |  | 1d | 2013-11-14 | 2013-11-14 | 19 | 0d |  | Operations Manager; Mover | 16h |
| 21 | 1.4.3 | Move Equipment |  | 0.5d | 2013-11-14 | 2013-11-14 | 20FF | 0d |  | Mover; Operations Manager | 8h |
| 22 | 1.4.4 | Remove existing furniture |  | 1d | 2013-11-15 | 2013-11-15 | 21 | 0d |  | Mover | 8h |
| 23 | 1.4.5 | Assemble new furniture |  | 2d | 2013-11-18 | 2013-11-19 | 22 | 0d |  | Mover; Space Planner | 32h |
| 24 | 1.4.6 | Return equipment |  | 1d | 2013-11-19 | 2013-11-20 | 23FS-0.5d | 0d |  | Mover; Operations Manager | 16h |
| 25 | 1.4.7 | Unpack workspace |  | 1d | 2013-11-20 | 2013-11-21 | 24 | 0d |  | Mover; Administrative Assistant | 16h |
| 26 | 1.4.8 | Workspace final clean |  | 1d | 2013-11-21 | 2013-11-22 | 25 | 0d |  | Janitor | 8h |
| 27 | 1.5 | Workspace remodel complete | milestone | 0d | 2013-11-22 | 2013-11-22 | 18 | 0d |  |  |  |
