# Office Remodel

Schedule from MS Project, 2013-10-07 to 2013-11-25, costs in $.
Workspace
Paper Division

## Calendars

- Standard: Mon-Fri 08:00-12:00, 13:00-17:00; Sat-Sun off.
- Freight Elevator: Mon-Fri 16:00-20:00; Sat-Sun off.

## Resources

| Resource | Group | Rate | Notes |
| --- | --- | --- | --- |
| President | contract |  |  |
| Office Manager | outside service |  |  |
| Administrative Assistant | management | 20 |  |
| Operations Manager | management | 31.15 |  |
| Space Planner | contract |  |  |
| Janitor | office staff | 16 | Use Cost Table B for construction clean up tasks. |
| Contractor | management |  |  |
| Mover | management |  |  |

## Schedule

| ID | WBS | Task | Type | Duration | Start | Finish | Predecessors | Total slack | Free slack | Calendar | Resources | Work | Cost |
| --- | --- | --- | --- | --- | --- | --- | --- | --- | --- | --- | --- | --- | --- |
| 1 | 1 | **Office Workspace Remodel** |  | 36d | 2013-10-07 | 2013-11-25 |  | 0d |  |  |  | 610h | 18,373.54 |
| 2 | 1.1 | **Space planning** |  | 12d | 2013-10-07 | 2013-10-22 |  | 0.88d |  |  |  | 256h | 2,384.62 |
| 3 | 1.1.1 | Interview space planners |  | 1w | 2013-10-07 | 2013-10-11 |  | 0.88d | 0d |  | President; Operations Manager; Office Manager | 120h | 1,246.15 |
| 4 | 1.1.2 | Hire space planner |  | 2d | 2013-10-14 | 2013-10-15 | 3 | 0.88d | 0d |  | President; Administrative Assistant | 32h | 320 |
| 5 | 1.1.3 | Meeting with space planner |  | 2d | 2013-10-16 | 2013-10-17 | 4 | 0.88d | 0d |  | President; Office Manager; Administrative Assistant; Operations Manager; Space Planner | 80h | 818.46 |
| 6 | 1.1.4 | Finalize space plan |  | 3d | 2013-10-18 | 2013-10-22 | 5 | 0.88d | 0d |  | Space Planner | 24h |  |
| 7 | 1.1.5 | Space plan complete | milestone | 0d | 2013-10-22 | 2013-10-22 | 6 | 0.88d | 0d |  |  |  |  |
| 8 | 1.2 | **Furniture selection** |  | 12d | 2013-10-17 | 2013-11-01 |  | 16d |  |  |  | 74h | 1,018.46 |
| 9 | 1.2.1 | Preview furniture selections |  | 2d | 2013-10-17 | 2013-10-18 | 5SS+1d | 16d | 0d |  | Office Manager; Operations Manager; Administrative Assistant | 48h | 818.46 |
| 10 | 1.2.2 | Select new furniture |  | 2d | 2013-10-21 | 2013-10-22 | 9 | 16d | 0d |  | Office Manager | 16h |  |
| 11 | 1.2.3 | Order new furniture |  | 0.5d | 2013-10-23 | 2013-10-23 | 10 | 16d | 0d |  | Administrative Assistant | 4h | 80 |
| 12 | 1.2.4 | Delivery time |  | 1.5w | 2013-10-23 | 2013-11-01 | 11 | 16d | 0d |  | Administrative Assistant [10%] | 6h | 120 |
| 13 | 1.2.5 | Furniture delivered | milestone | 0d | 2013-11-01 | 2013-11-01 | 12 | 16d |  |  |  |  |  |
| 14 | 1.3 | **Remodel workspace** |  | 14d | 2013-10-23 | 2013-11-11 |  | 0.88d | 0d |  |  | 144h | 13,496.92 |
| 15 | 1.3.1 | Hire contractor |  | 4d | 2013-10-23 | 2013-10-28 | 7 | 0.88d | 0d |  | President; Operations Manager | 64h | 996.92 |
| 16 | 1.3.2 | Remodel workspace |  | 2w | 2013-10-29 | 2013-11-11 | 15 | 0.88d | 0d |  | Contractor | 80h | 12,500 |
| 17 | 1.3.3 | Remodel complete | milestone | 0d | 2013-11-11 | 2013-11-11 | 16 | 0.88d |  |  |  |  |  |
| 18 | 1.4 | **New workspace** |  | 10d | 2013-11-12 | 2013-11-25 | 14 | 0d |  |  |  | 136h | 1,473.54 |
| 19 | 1.4.1 | Hire mover |  | 2d | 2013-11-12 | 2013-11-13 |  | 0.88d | 0d |  | Office Manager; Operations Manager | 32h | 498.46 |
| 20 | 1.4.2 | Pack workspace |  | 1d | 2013-11-14 | 2013-11-14 | 19 | 0.88d | 0d |  | Operations Manager; Mover | 16h | 249.23 |
| 21 | 1.4.3 | Move Equipment |  | 0.5d | 2013-11-14 | 2013-11-14 | 20FF | 0.88d | 0d |  | Mover; Operations Manager | 8h | 124.62 |
| 22 | 1.4.4 | Remove existing furniture |  | 1d | 2013-11-14 | 2013-11-18 | 21 | 0.38d |  | Freight Elevator | Mover | 8h |  |
| 23 | 1.4.5 | Assemble new furniture |  | 2d | 2013-11-19 | 2013-11-20 | 22 | 0.5d | 0d |  | Mover; Space Planner | 32h |  |
| 24 | 1.4.6 | Return equipment |  | 1d | 2013-11-20 | 2013-11-21 | 23FS-0.5d | 0.5d | 0d |  | Mover; Operations Manager | 16h | 249.23 |
| 25 | 1.4.7 | Unpack workspace |  | 1d | 2013-11-21 | 2013-11-22 | 24 | 0.5d |  |  | Mover; Administrative Assistant | 16h | 160 |
| 26 | 1.4.8 | Workspace final clean |  | 1d | 2013-11-25 | 2013-11-25 | 25 | 0d |  |  | Janitor | 8h | 192 |
| 27 | 1.5 | Workspace remodel complete | milestone | 0d | 2013-11-25 | 2013-11-25 | 18 | 0d |  |  |  |  |  |
