# Office Remodel

Schedule from MS Project, 2013-10-07 to 2013-11-20, costs in $.
Workspace
Paper Division

## Calendars

- Standard: Mon-Fri 08:00-12:00, 13:00-17:00; Sat-Sun off.
- Freight Elevator: Mon-Fri 16:00-20:00; Sat-Sun off.

## Resources

| Resource | Group | Rate |
| --- | --- | --- |
| President | contract |  |
| Office Manager | outside service |  |
| Administrative Assistant | management | 20 |
| Operations Manager | management | 31.15 |
| Space Planner | contract |  |
| Janitor | office staff | 16 |
| Contractor | management |  |
| Mover | management |  |

## Schedule

| ID | WBS | Task | Type | Duration | Start | Finish | Predecessors | Total slack | Free slack | Constraint | Deadline | Calendar | Resources | Work | Cost |
| --- | --- | --- | --- | --- | --- | --- | --- | --- | --- | --- | --- | --- | --- | --- | --- |
| 1 | 1 | **Office Workspace Remodel** |  | 32d | 2013-10-07 | 2013-11-20 |  | 0d |  |  |  |  |  | 592h | 6,154.77 |
| 2 | 1.1 | **Space planning** |  | 12d | 2013-10-07 | 2013-10-22 |  | 0.88d |  |  |  |  |  | 222h | 2,384.62 |
| 3 | 1.1.1 | Interview space planners |  | 1w | 2013-10-07 | 2013-10-11 |  | 0.88d | 0d |  |  |  | Operations Manager; Office Manager; President [25%] | 86h | 1,246.15 |
| 4 | 1.1.2 | Hire space planner |  | 2d | 2013-10-14 | 2013-10-15 | 3 | 0.88d | 0d |  |  |  | President; Administrative Assistant | 32h | 320 |
| 5 | 1.1.3 | Meeting with space planner |  | 2d | 2013-10-16 | 2013-10-17 | 4 | 0.88d | 0d |  |  |  | President; Office Manager; Administrative Assistant; Operations Manager; Space Planner | 80h | 818.46 |
| 6 | 1.1.4 | Finalize space plan |  | 3d | 2013-10-18 | 2013-10-22 | 5 | 0.88d | 0d |  | 2013-10-23 |  | Space Planner | 24h |  |
| 7 | 1.1.5 | Space plan complete | milestone | 0d | 2013-10-22 | 2013-10-22 | 6 | 0.88d | 0d |  |  |  |  |  |  |
| 8 | 1.2 | **Furniture selection** |  | 11d | 2013-10-17 | 2013-10-31 |  | 13d |  |  |  |  |  | 74h | 1,267.69 |
| 9 | 1.2.1 | Preview furniture selections |  | 2d | 2013-10-17 | 2013-10-18 | 5SS+1d | 13d | 0d |  |  |  | Office Manager; Operations Manager; Administrative Assistant | 48h | 818.46 |
| 10 | 1.2.2 | Select new furniture |  | 1d | 2013-10-21 | 2013-10-21 | 9 | 13d | 0d |  |  |  | Office Manager; Operations Manager | 16h | 249.23 |
| 11 | 1.2.3 | Order new furniture |  | 0.5d | 2013-10-22 | 2013-10-22 | 10 | 13d | 0d |  |  |  | Administrative Assistant | 4h | 80 |
| 12 | 1.2.4 | Delivery time |  | 1.5w | 2013-10-22 | 2013-10-31 | 11 | 13d | 0d | finish no earlier than 2009-11-01 |  |  | Administrative Assistant [10%] | 6h | 120 |
| 13 | 1.2.5 | Furniture delivered | milestone | 0d | 2013-10-31 | 2013-10-31 | 12 | 13d |  |  |  |  |  |  |  |
| 14 | 1.3 | **Remodel workspace** |  | 9d | 2013-10-23 | 2013-11-04 |  | 0.88d | 0d |  |  |  |  | 144h | 996.92 |
| 15 | 1.3.1 | Hire contractor |  | 4d | 2013-10-23 | 2013-10-28 | 7 | 0.88d | 0d |  |  |  | President; Operations Manager | 64h | 996.92 |
| 16 | 1.3.2 | Remodel workspace |  | 1w | 2013-10-29 | 2013-11-04 | 15 | 0.88d | 0d |  |  |  | Contractor [200%] | 80h |  |
| 17 | 1.3.3 | Remodel complete | milestone | 0d | 2013-11-04 | 2013-11-04 | 16 | 0.88d |  |  |  |  |  |  |  |
| 18 | 1.4 | **New workspace** |  | 10.5d | 2013-11-05 | 2013-11-19 | 14 | 0.5d |  |  |  |  |  | 152h | 1,505.54 |
| 19 | 1.4.1 | Hire mover |  | 2d | 2013-11-05 | 2013-11-06 | 15SS | 0.88d | 0d |  |  |  | Office Manager; Operations Manager | 32h | 498.46 |
| 20 | 1.4.2 | Pack workspace |  | 1d | 2013-11-07 | 2013-11-07 | 19, 15 | 0.88d | 0d |  |  |  | Operations Manager; Mover | 16h | 249.23 |
| 21 | 1.4.3 | Move Equipment |  | 0.5d | 2013-11-07 | 2013-11-07 | 20FF | 0.88d | 0d |  |  |  | Mover; Operations Manager | 8h | 124.62 |
| 22 | 1.4.4 | Remove existing furniture |  | 1d | 2013-11-07 | 2013-11-11 | 21 | 0.38d |  |  |  | Freight Elevator | Mover | 8h |  |
| 23 | 1.4.5 | Assemble new furniture |  | 2d | 2013-11-12 | 2013-11-13 | 22, 16 | 0d |  |  | 2013-11-13 |  | Mover; Space Planner [125%] | 32h |  |
| 24 | 1.4.6 | Return equipment |  | 1d | 2013-11-13 | 2013-11-14 | 23FS-0.5d | 0.5d | 0d |  |  |  | Mover; Operations Manager | 16h | 249.23 |
| 25 | 1.4.7 | Unpack workspace |  | 2d | 2013-11-14 | 2013-11-18 | 24 | 0.5d | 0d |  |  |  | Mover; Administrative Assistant | 32h | 320 |
| 26 | 1.4.8 | Workspace final clean |  | 1d | 2013-11-18 | 2013-11-19 | 25 | 0.5d |  |  |  |  | Janitor [50%]; Mover [50%] | 8h | 64 |
| 27 | 1.5 | Workspace remodel complete | milestone | 0d | 2013-11-20 | 2013-11-20 | 26 | 0d |  | must finish on 2013-11-20 |  |  |  |  |  |
