# Office Remodel

Schedule from MS Project, 2013-10-07 to 2013-11-12, status date 2010-01-09, costs in $, A marks actual dates.
Workspace
Paper Division

## Calendars

- Standard: Mon-Fri 08:00-12:00, 13:00-17:00; Sat-Sun off.

## Resources

| Resource | Group | Rate | Notes |
| --- | --- | --- | --- |
| President | management | 38.46 |  |
| Office Manager | management | 25 |  |
| Administrative Assistant | office staff | 20 |  |
| Operations Manager | management | 31.15 |  |
| Space Planner | outside service | 40 |  |
| Janitor | maintenance | 16 | The cost rate table B is for construction cleaning tasks. |
| Contractor | contract |  |  |
| Mover | contract | 25 |  |

## Schedule

| ID | WBS | Task | Type | Duration | Start | Finish | Predecessors | Complete | Remaining | Total slack | Free slack | Constraint | Deadline | Resources | Work | Actual work | Cost | Actual cost |
| --- | --- | --- | --- | --- | --- | --- | --- | --- | --- | --- | --- | --- | --- | --- | --- | --- | --- | --- |
| 1 | 1 | **Office Workspace Remodel** |  | 27d | 2013-10-07 A | 2013-11-12 |  | 88% | 3.38d | 0d |  |  |  |  | 600h | 520h | 27,996.31 | 13,371.08 |
| 2 | 1.1 | **Space planning** |  | 13d | 2013-10-07 A | 2013-10-23 A |  | 100% |  |  |  |  |  |  | 246h | 246h | 7,615.38 | 7,615.38 |
| 3 | 1.1.1 | Interview space planners |  | 1w | 2013-10-07 A | 2013-10-11 A |  | 100% |  |  |  |  |  | Operations Manager; Office Manager; President [25%] | 86h | 86h | 2,476.92 | 2,476.92 |
| 4 | 1.1.2 | Hire space planner |  | 1d | 2013-10-14 A | 2013-10-14 A | 3 | 100% |  |  |  |  |  | President; Administrative Assistant | 16h | 16h | 467.69 | 467.69 |
| 5 | 1.1.3 | Meeting with space planner |  | 3d | 2013-10-15 A | 2013-10-17 A | 4 | 100% |  |  |  |  |  | President; Office Manager; Administrative Assistant; Operations Manager; Space Planner | 120h | 120h | 3,710.77 | 3,710.77 |
| 6 | 1.1.4 | Finalize space plan |  | 3d | 2013-10-21 A | 2013-10-23 A | 5 | 100% |  |  |  |  | 2006-10-23 | Space Planner | 24h | 24h | 960 | 960 |
| 7 | 1.1.5 | Space plan complete | milestone | 0d | 2013-10-22 A | 2013-10-22 A | 6 | 100% |  |  |  |  |  |  |  |  |  |  |
| 8 | 1.2 | **Furniture selection** |  | 10.5d | 2013-10-21 A | 2013-11-04 A |  | 100% |  |  |  |  |  |  | 74h | 74h | 1,867.69 | 1,867.69 |
| 9 | 1.2.1 | Preview furniture selections |  | 2d | 2013-10-21 A | 2013-10-22 A | 5SS+1d | 100% |  |  |  |  |  | Office Manager; Operations Manager; Administrative Assistant | 48h | 48h | 1,218.46 | 1,218.46 |
| 10 | 1.2.2 | Select new furniture |  | 1.5d | 2013-10-22 A | 2013-10-23 A | 9 | 100% |  |  |  |  |  | Office Manager; Operations Manager | 16h | 16h | 449.23 | 449.23 |
| 11 | 1.2.3 | Order new furniture |  | 0.5d | 2013-10-23 A | 2013-10-23 A | 10 | 100% |  |  |  |  |  | Administrative Assistant | 4h | 4h | 80 | 80 |
| 12 | 1.2.4 | Delivery time |  | 1.5w | 2013-10-24 A | 2013-11-04 A | 11 | 100% |  |  |  | finish no earlier than 2011-11-02 |  | Administrative Assistant [10%] | 6h | 6h | 120 | 120 |
| 13 | 1.2.5 | Furniture delivered | milestone | 0d | 2013-11-01 A | 2013-11-01 A | 12 | 100% |  |  |  |  |  |  |  |  |  |  |
| 14 | 1.3 | **Remodel workspace** |  | 9d | 2013-10-23 A | 2013-11-05 |  | 94% | 0.5d | 6d |  |  |  |  | 144h | 136h | 14,727.69 | 2,227.69 |
| 15 | 1.3.1 | Hire contractor |  | 4d | 2013-10-23 A | 2013-10-28 A | 7 | 100% |  |  |  |  |  | President; Operations Manager | 64h | 64h | 2,227.69 | 2,227.69 |
| 16 | 1.3.2 | Remodel workspace |  | 1w | 2013-10-29 A | 2013-11-04 | 15 | 90% | 0.1w | 1.5d | 0d |  |  | Contractor [200%] | 80h | 72h | 12,500 |  |
| 17 | 1.3.3 | Remodel complete | milestone | 0d | 2013-11-05 | 2013-11-05 | 16 |  |  | 6d |  | start no earlier than 2013-11-05 |  |  |  |  |  |  |
| 18 | 1.4 | **New workspace** |  | 15d | 2013-10-23 A | 2013-11-12 |  | 57% | 6.52d | 0d |  |  |  |  | 136h | 64h | 3,785.54 | 1,660.31 |
| 19 | 1.4.1 | Hire mover |  | 4d | 2013-10-23 A | 2013-10-28 A | 15SS | 100% |  |  |  |  |  | Office Manager | 32h | 32h | 800 | 800 |
| 20 | 1.4.2 | Pack workspace |  | 1d | 2013-10-29 A | 2013-10-29 A | 19, 15 | 100% |  |  |  |  |  | President; Janitor | 16h | 16h | 435.69 | 435.69 |
| 21 | 1.4.3 | Move Equipment |  | 0.5d | 2013-10-29 A | 2013-10-29 A | 20FF | 100% |  |  |  |  |  | Mover; Operations Manager | 8h | 8h | 224.62 | 224.62 |
| 22 | 1.4.4 | Remove existing furniture |  | 1d | 2013-10-30 A | 2013-10-30 A | 21 | 100% |  |  |  |  |  | Mover | 8h | 8h | 200 | 200 |
| 23 | 1.4.5 | Assemble new furniture |  | 2d | 2013-11-05 | 2013-11-06 | 22, 16 |  |  | 1.5d | 0d |  |  | Office Manager; Space Planner [116.7%] | 32h |  | 1,120 |  |
| 24 | 1.4.6 | Return equipment |  | 1d | 2013-11-06 | 2013-11-07 | 23FS-0.5d |  |  | 1.5d |  |  |  | Mover; Operations Manager | 16h |  | 449.23 |  |
| 25 | 1.4.7 | Unpack workspace |  | 1d | 2013-11-11 | 2013-11-11 | 24 |  |  | 0d |  | start no earlier than 2013-11-09 |  | Mover; Administrative Assistant | 16h |  | 360 |  |
| 26 | 1.4.8 | Workspace final clean |  | 1d | 2013-11-12 | 2013-11-12 | 25 |  |  | 0d |  | start no earlier than 2013-11-09 |  | Janitor [50%]; Mover [50%] | 8h |  | 196 |  |
| 27 | 1.5 | Workspace remodel complete | milestone | 0d | 2013-11-12 | 2013-11-12 | 18 |  |  | 0d |  | start no earlier than 2013-11-12 |  |  |  |  |  |  |
